# OCIW

Schedule from MS Project, 2005-03-01 to 2005-08-31.
OCIW

## Calendars

- Standard: Mon-Fri 08:00-12:00, 13:00-17:00; Sat-Sun off.

## Schedule

| ID | WBS | Task | Duration | Start | Finish | Predecessors | Baseline start | Baseline finish | Baseline duration | Total slack | Free slack | Constraint |
| --- | --- | --- | --- | --- | --- | --- | --- | --- | --- | --- | --- | --- |
| 1 | 1 | **IMACS** | 132d? | 2005-03-01 | 2005-08-31 |  | 2005-03-01 | 2005-05-20 | 59d | 0d |  |  |
| 2 | 1.1 | **IMACS Design** | 132d | 2005-03-01 | 2005-08-31 |  | 2005-03-01 | 2005-05-20 | 59d | 0d |  |  |
| 3 | 1.1.1 | **GISMO** | 25d | 2005-07-05 | 2005-08-08 |  | 2005-03-01 | 2005-03-01 | 1d | 17d |  |  |
| 4 | 1.1.1.1 | Review Optics Layout | 24d | 2005-07-05 | 2005-08-05 |  |  |  |  | 17d | 0d | finish no earlier than 2005-08-05 |
| 5 | 1.1.1.2 | Mechanical Design | 1d | 2005-08-08 | 2005-08-08 | 4 |  |  |  | 17d |  |  |
| 6 | 1.1.1.3 | Fabrication | 1d | 2005-08-08 | 2005-08-08 | 4 |  |  |  | 17d |  |  |
| 7 | 1.1.2 | **Disperser Server** | 132d | 2005-03-01 | 2005-08-31 |  | 2005-03-01 | 2005-05-20 | 59d | 0d |  |  |
| 8 | 1.1.2.1 | **MMTF** | 132d | 2005-03-01 | 2005-08-31 |  | 2005-03-01 | 2005-05-20 | 59d | 0d |  |  |
| 9 | 1.1.2.1.1 | Mechanical Design | 23d | 2005-03-01 | 2005-03-31 |  |  |  |  | 109d |  |  |
| 10 | 1.1.2.1.2 | Assembly and Test Setup Design | 23d | 2005-08-01 | 2005-08-31 |  |  |  |  | 0d |  | start no earlier than 2005-08-01 |
| 11 | 1.1.2.1.3 | MMTF Hartmann Alignment Baffle | 1d | 2005-03-01 | 2005-03-01 |  |  |  |  | 131d |  |  |
| 12 | 1.1.2.1.4 | Pack and ship | 1d | 2005-03-01 | 2005-03-01 |  |  |  |  | 131d |  |  |
| 13 | 1.1.2.1.5 | Pre-ship review | 1d | 2005-03-01 | 2005-03-01 |  |  |  |  | 131d |  |  |
| 14 | 1.1.2.2 | **LDP** | 132d | 2005-03-01 | 2005-08-31 |  | 2005-03-01 | 2005-03-01 | 1d | 0d |  |  |
| 15 | 1.1.2.2.1 | Mechanical Design | 17d | 2005-05-09 | 2005-05-31 |  | 2005-03-01 | 2005-03-01 | 1d | 66d |  | finish no earlier than 2005-05-31 |
| 16 | 1.1.2.2.2 | Optics Fabrication | 43d | 2005-07-04 | 2005-08-31 |  | 2005-03-01 | 2005-03-01 | 1d | 0d |  | finish no earlier than 2005-08-31 |
| 17 | 1.1.2.2.3 | Fabrication | 1d | 2005-03-01 | 2005-03-01 |  | 2005-03-01 | 2005-03-01 | 1d | 131d |  |  |
| 18 | 1.1.2.3 | **150 l/mm Grism** | 1d | 2005-03-01 | 2005-03-01 |  | 2005-03-01 | 2005-03-01 | 1d | 131d |  |  |
| 19 | 1.1.2.3.1 | Mechanical Design | 1d | 2005-03-01 | 2005-03-01 |  | 2005-03-01 | 2005-03-01 | 1d | 131d |  |  |
| 20 | 1.1.2.3.2 | Optics Fabrication | 1d | 2005-03-01 | 2005-03-01 |  | 2005-03-01 | 2005-03-01 | 1d | 131d |  |  |
| 21 | 1.1.2.3.3 | Fabrication | 1d | 2005-03-01 | 2005-03-01 |  | 2005-03-01 | 2005-03-01 | 1d | 131d |  |  |
| 22 | 1.1.2.4 | 600 l/mm Grism Baffle | 1d | 2005-03-01 | 2005-03-01 |  | 2005-03-01 | 2005-03-01 | 1d | 131d |  |  |
| 23 | 1.1.2.5 | DSS Dummy | 1d | 2005-03-01 | 2005-03-01 |  | 2005-03-01 | 2005-03-01 | 1d | 131d |  |  |
| 24 | 1.1.2.6 | Hartmann Baffle Redesign | 1d | 2005-03-01 | 2005-03-01 |  | 2005-03-01 | 2005-03-01 | 1d | 131d |  |  |

Notes:
- 8: ·fabrication complete 15 Apr 05 / ·base and support bracket sent for fab 29 Mar 05 / ·solids finished 28 Feb 05 / ·MMTF mount designed and fabricated for test fit
- 18: ·Blank fabrication (Glass Fab) - arrived 1 Mar 05 / ·Grinding and Polishing (TORC) / ·Coating / ·Ruling (RGL) / ·design and fab mounting
- 19: 21 Apr 05 / ·solid design completed / ·some parts sent for fabrication / ·modified base plate and truss bse blocks / ·need dwg for cell
- 20: 31 March 05 / ·Sent RFQ to Joe Apples @ TORC
- 22: ·check cost of ZTR178 / ·look into modifying current baffle with cutout for cable wrap clearance / - done 14 Mar 05 / ·revise dwg to include details of mod - cutout 15mm deep x 50 mm wide
- 24: 22 Apr 05 / ·anodizing complete / ·pvc and metal Hartmann masks complete / 11 Mar 05 / ·fab complete / ·sent for anodize / Redisgn considerations: / ·add mounting tabs to base ring

| ID | WBS | Task | Duration | Start | Finish | Baseline start | Baseline finish | Baseline duration | Total slack | Constraint |
| --- | --- | --- | --- | --- | --- | --- | --- | --- | --- | --- |
| 25 | 1.2 | **Mosaic #2** | 1d? | 2005-03-01 | 2005-03-01 |  |  |  | 131d |  |
| 26 | 1.2.1 | Review Drawings and Solids | 1d? | 2005-03-01 | 2005-03-01 |  |  |  | 131d |  |
| 27 | 1.3 | **IMACS Repair & Maintenance** | 1d | 2005-03-01 | 2005-03-01 | 2005-03-01 | 2005-05-20 | 59d | 131d |  |
| 28 | 1.3.1 | **Disperser Server** | 1d | 2005-03-01 | 2005-03-01 | 2005-03-01 | 2005-03-01 | 1d | 131d |  |
| 29 | 1.3.1.1 | DSS Change Tool Drawing Revisions | 1d | 2005-03-01 | 2005-03-01 | 2005-03-01 | 2005-03-01 | 1d | 131d |  |
| 30 | 1.3.1.2 | DSS Spares | 1d | 2005-03-01 | 2005-03-01 | 2005-03-01 | 2005-03-01 | 1d | 131d |  |
| 31 | 1.3.2 | **Cameras** | 1d | 2005-03-01 | 2005-03-01 |  |  |  | 131d |  |
| 32 | 1.3.2.1 | f/2 Volume Compensator | 1d | 2005-03-01 | 2005-03-01 | 2005-03-01 | 2005-03-01 | 1d | 131d |  |
| 33 | 1.3.3 | **Dewar Cooling and Plumbing** | 1d | 2005-03-01 | 2005-03-01 | 2005-05-20 | 2005-05-20 | 1d | 131d |  |
| 34 | 1.3.3.1 | Spec and Order Hardware | 1d | 2005-03-01 | 2005-03-01 |  |  |  | 131d |  |
| 35 | 1.3.4 | **Filter Server** | 1d | 2005-03-01 | 2005-03-01 | 2005-03-01 | 2005-03-01 | 1d | 131d |  |
| 36 | 1.3.4.1 | Filter Assembly Modifications | 1d | 2005-03-01 | 2005-03-01 | 2005-03-01 | 2005-03-01 | 1d | 131d |  |
| 37 | 1.4 | **IMACS Commissioning** | 1d | 2005-03-01 | 2005-03-01 | 2005-03-01 | 2005-03-01 | 1d | 131d |  |
| 38 | 1.4.1 | **Mechanical Documentation** | 1d | 2005-03-01 | 2005-03-01 | 2005-03-01 | 2005-03-01 | 1d | 131d |  |
| 39 | 1.4.1.1 | Mechanical Reports | 1d | 2005-03-01 | 2005-03-01 | 2005-03-01 | 2005-03-01 | 1d | 131d |  |
| 40 | 1.4.1.2 | Drawings | 1d | 2005-03-01 | 2005-03-01 | 2005-03-01 | 2005-03-01 | 1d | 131d |  |
| 41 | 1.4.2 | Troubleshooting Documention | 1d | 2005-03-01 | 2005-03-01 | 2005-03-01 | 2005-03-01 | 1d | 131d |  |
| 42 | 1.4.3 | Spare Parts Catalogue | 1d | 2005-03-01 | 2005-03-01 | 2005-03-01 | 2005-03-01 | 1d | 131d |  |
| 44 | 2 | **FourStar** | 50d | 2005-03-01 | 2005-05-09 | 2005-03-01 | 2005-03-01 | 1d | 82d |  |
| 45 | 2.1 | **FourStar FEA** | 1d | 2005-03-01 | 2005-03-01 | 2005-03-01 | 2005-03-01 | 1d | 131d |  |
| 46 | 2.1.1 | Front Doublet Analysis | 1d | 2005-03-01 | 2005-03-01 | 2005-03-01 | 2005-03-01 | 1d | 131d |  |
| 47 | 2.1.2 | L06 Analysis | 1d | 2005-03-01 | 2005-03-01 | 2005-03-01 | 2005-03-01 | 1d | 131d |  |
| 48 | 2.1.3 | G10 Flexure Heat Transfer Analysis | 1d | 2005-03-01 | 2005-03-01 | 2005-03-01 | 2005-03-01 | 1d | 131d |  |
| 49 | 2.2 | **FourStar Mechanical** | 50d | 2005-03-01 | 2005-05-09 | 2005-03-01 | 2005-05-09 | 50d | 82d |  |
| 50 | 2.2.1 | Cart 2 | 1d | 2005-05-09 | 2005-05-09 | 2005-05-09 | 2005-05-09 | 1d | 82d | start no earlier than 2005-05-09 |
| 51 | 2.2.2 | Filter Wheel Bearing design | 1d | 2005-03-01 | 2005-03-01 | 2005-03-01 | 2005-03-01 | 1d | 131d |  |

Notes:
- 29: ·rename 3610003 to Slide/Lock Bar / ·rename 3610004 to Strap Lift Bar / ·revise 3610007 with M8 threaded hole
- 30: ·fab pin blocks - 5 sets
- 32: 15 Apr 05 / ·collected 'soft' O-Rings and heat shrink / ·test assembly with opical couplong / ·consider acquiring O-Rings of known material
- 33: ·order cooling plates / ·order plumbing hardware and hoses
- 34: ·Swagelok QC hardware has 1/8" male NPT fittings on both body and stem. / ·directional flow from body to stem
- 36: 21 Apr 05 / ·aperture baffle clip design complete / ·review with Dressler / ·work on dwg / 14 Apr 05 / ·consider new baffle instead of corner clips

| ID | WBS | Task | Duration | Start | Finish | Baseline start | Baseline finish | Baseline duration | Total slack |
| --- | --- | --- | --- | --- | --- | --- | --- | --- | --- |
| 53 | 3 | **Magellan** | 1d? | 2005-03-01 | 2005-03-01 | 2005-03-01 | 2005-03-01 | 1d | 131d |
| 54 | 3.1 | MMIRS WFCCD Slit Mask Laser Mill Asembly | 1d? | 2005-03-01 | 2005-03-01 |  |  |  | 131d |
| 55 | 3.2 | f/5 Baffle System | 1d | 2005-03-01 | 2005-03-01 | 2005-03-01 | 2005-03-01 | 1d | 131d |
